# Gantt-Task allocation 11-05-18

How a schedule from MS Project changed from version to version. A marks actual dates.

## Version 1 (data date 2018-05-11, saved 2018-05-14, file Gantt-Task allocation 11-05-18.mpp)

| ID | WBS | Task | Duration | Start | Finish | Predecessors | Complete | Total float | Constraint |
| --- | --- | --- | --- | --- | --- | --- | --- | --- | --- |
| 1 | 1 | **Outdoor Intelligent Shader** | 75d | 2018-02-26 A | 2018-06-25 |  | 61% | 0d |  |
| 2 | 1.1 | **Analysing** | 3d | 2018-02-26 A | 2018-02-28 A |  | 100% |  |  |
| 3 | 1.1.1 | **Planning** | 3d | 2018-02-26 A | 2018-02-28 A |  | 100% |  |  |
| 4 |  | Problem | 1d | 2018-02-26 A | 2018-02-26 A |  | 100% |  |  |
| 5 | 1.1.1.2 | **Target Audience** | 1d | 2018-02-26 A | 2018-02-26 A |  | 100% |  |  |
| 6 |  | Research User | 1d | 2018-02-26 A | 2018-02-26 A |  | 100% |  |  |
| 7 |  | Existing Products | 1d | 2018-02-27 A | 2018-02-27 A | 5 | 100% |  |  |
| 8 | 1.1.1.4 | **Economical Analisys** | 1d | 2018-02-27 A | 2018-02-27 A | 7SS | 100% |  |  |
| 9 |  | SWOT | 1d | 2018-02-27 A | 2018-02-27 A |  | 100% |  |  |
| 10 |  | Requirements | 1d | 2018-02-28 A | 2018-02-28 A | 7 | 100% |  |  |
| 11 | 1.2 | **Ideation** | 3d | 2018-03-01 A | 2018-03-05 A | 2 | 100% |  |  |
| 12 | 1.2.1 | **Analysing** | 3d | 2018-03-01 A | 2018-03-05 A |  | 100% |  |  |
| 13 | 1.2.1.1 | **Product View** | 1d | 2018-03-01 A | 2018-03-01 A |  | 100% |  |  |
| 14 |  | Intentions | 1d | 2018-03-01 A | 2018-03-01 A |  | 100% |  |  |
| 15 |  | Perception | 1d | 2018-03-01 A | 2018-03-01 A |  | 100% |  |  |
| 16 |  | Aesthetics | 1d | 2018-03-01 A | 2018-03-01 A |  | 100% |  |  |
| 17 |  | Product Ideas(20-40 ideas) | 1d | 2018-03-01 A | 2018-03-01 A | 13SS | 100% |  |  |
| 18 |  | 10 improved ideas | 1d | 2018-03-02 A | 2018-03-02 A | 17 | 100% |  |  |
| 19 |  | Morfological Research | 1d | 2018-03-05 A | 2018-03-05 A | 18 | 100% |  |  |
| 20 |  | Gantt chart | 0d | 2018-03-05 A | 2018-03-05 A |  | 100% |  | start no earlier than 2018-03-05 |
| 21 |  | Task identification | 0d | 2018-03-05 A | 2018-03-05 A |  | 100% |  | start no earlier than 2018-03-05 |
| 22 |  | Task allocation | 0d | 2018-03-05 A | 2018-03-05 A |  | 100% |  | start no earlier than 2018-03-05 |
| 23 | 1.3 | **Concept** | 31d | 2018-03-06 A | 2018-04-25 A | 11 | 100% |  |  |
| 24 | 1.3.1 | **Analysing** | 31d | 2018-03-06 A | 2018-04-25 A |  | 100% |  |  |
| 25 |  | 3 concepts | 1d | 2018-03-06 A | 2018-03-06 A |  | 100% |  |  |
| 26 | 1.3.1.2 | **Final Concept** | 30d | 2018-03-07 A | 2018-04-25 A | 25 | 100% |  |  |
| 27 |  | Black Box, structural drafts | 4d | 2018-03-07 A | 2018-03-12 A |  | 100% |  |  |
| 28 |  | Upload black Box, structural drafts | 0d | 2018-03-12 A | 2018-03-12 A | 27 | 100% |  |  |
| 29 |  | Detailed schematics, structural drawings,cardboard model | 15d | 2018-03-13 A | 2018-04-02 A | 27 | 100% |  |  |
| 30 |  | Upload Detailed schematics, structural drawings,cardboard model | 0d | 2018-04-02 A | 2018-04-02 A | 29 | 100% |  | finish no earlier than 2018-04-02 |
| 31 |  | Choosing materials | 4d | 2018-04-03 A | 2018-04-06 A | 29 | 100% |  |  |
| 32 |  | Upload selection of materials and components | 0d | 2018-04-04 A | 2018-04-04 A | 31 | 100% |  |  |
| 33 |  | Search local providers | 13d | 2018-04-09 A | 2018-04-25 A | 31 | 100% |  |  |
| 34 |  | Upload selection of local providers and final list of materials and components | 0d | 2018-04-25 A | 2018-04-25 A | 33 | 100% |  |  |
| 35 | 1.4 | **Interim Presentation** | 11d | 2018-04-05 A | 2018-04-19 A | 32 | 100% |  |  |
| 36 | 1.4.1 | **Planning** | 11d | 2018-04-05 A | 2018-04-19 A |  | 100% |  |  |
| 37 |  | Evaluation meetings | 11d | 2018-04-05 A | 2018-04-19 A |  | 100% |  |  |
| 38 |  | Upload deliverables | 0d | 2018-04-14 A | 2018-04-14 A |  | 100% |  | start no earlier than 2018-04-14 |
| 39 |  | Presentation | 0d | 2018-04-19 A | 2018-04-19 A | 37 | 100% |  |  |
| 40 | 1.5 | **Construction** | 14d | 2018-04-26 A | 2018-05-22 | 23 | 44% | 0d |  |
| 41 | 1.5.1 | **Planning** | 14d | 2018-04-26 A | 2018-05-22 |  | 44% | 0d |  |
| 42 | 1.5.1.1 | **Hardware** | 14d | 2018-04-26 A | 2018-05-22 |  | 46% | 0d |  |
| 43 |  | Process material matrix | 1d | 2018-04-26 A | 2018-04-26 A |  | 100% |  |  |
| 44 | 1.5.1.1.2 | **Materials** | 1d | 2018-04-27 A | 2018-04-27 A | 43 | 100% |  |  |
| 45 |  | Sustainability | 1d | 2018-04-27 A | 2018-04-27 A |  | 100% |  |  |
| 46 | 1.5.1.1.3 | **Processes** | 12d | 2018-04-30 A | 2018-05-22 | 44 | 42% | 0d |  |
| 47 |  | Shaping | 12d | 2018-04-30 A | 2018-05-22 |  | 42% | 0d |  |
| 48 |  | Joining | 12d | 2018-04-30 A | 2018-05-22 |  | 42% | 0d |  |
| 49 | 1.5.1.2 | **Software** | 12d | 2018-04-30 A | 2018-05-22 | 46SS | 42% | 0d |  |
| 50 |  | Materials | 12d | 2018-04-30 A | 2018-05-22 |  | 42% | 0d |  |
| 51 |  | Specifics | 12d | 2018-04-30 A | 2018-05-22 |  | 42% | 0d |  |
| 52 |  | Upload refined report | 0d | 2018-05-02 A | 2018-05-02 A |  | 100% |  | start no earlier than 2018-05-02 |
| 53 | 1.6 | **Testing** | 11d | 2018-05-23 | 2018-06-06 | 40 |  | 0d |  |
| 54 |  | Component tests | 11d | 2018-05-23 | 2018-06-06 |  |  | 0d |  |
| 55 |  | Upload functional tests | 0d | 2018-06-06 | 2018-06-06 | 54 |  | 0d |  |
| 56 | 1.7 | **Report** | 10d | 2018-06-07 | 2018-06-20 | 53 |  | 0d |  |
| 57 |  | Write final report | 10d | 2018-06-07 | 2018-06-20 |  |  | 0d |  |
| 58 |  | Upload final report | 0d | 2018-06-20 | 2018-06-20 | 57 |  | 0d |  |
| 59 |  | Upload Deliverables | 0d | 2018-06-20 | 2018-06-20 | 57 |  | 0d |  |
| 60 | 1.8 | **Final Presentation** | 3d | 2018-06-21 | 2018-06-25 | 56 |  | 0d |  |
| 61 |  | Evaluation meetings | 3d | 2018-06-21 | 2018-06-25 |  |  | 0d |  |
| 62 |  | Presentation | 0d | 2018-06-25 | 2018-06-25 | 61 |  | 0d |  |

## Version 2 (data date 2018-05-25, saved 2018-05-31, file Gantt-Task allocation 25-05-18.mpp)

Last finish stays 2018-06-25. Complete tasks 29 → 33.

Changed:

| ID | Task | Start | Finish | Complete | Total float |
| --- | --- | --- | --- | --- | --- |
| 1 | **Outdoor Intelligent Shader** |  |  | 61% → 84% |  |
| 40 | **Construction** |  | 2018-05-22 A | 44% → 100% | 0d → none |
| 41 | **Planning** |  | 2018-05-22 A | 44% → 100% | 0d → none |
| 42 | **Hardware** |  | 2018-05-22 A | 46% → 100% | 0d → none |
| 46 | **Processes** |  | 2018-05-22 A | 42% → 100% | 0d → none |
| 47 | Shaping |  | 2018-05-22 A | 42% → 100% | 0d → none |
| 48 | Joining |  | 2018-05-22 A | 42% → 100% | 0d → none |
| 49 | **Software** |  | 2018-05-22 A | 42% → 100% | 0d → none |
| 50 | Materials |  | 2018-05-22 A | 42% → 100% | 0d → none |
| 51 | Specifics |  | 2018-05-22 A | 42% → 100% | 0d → none |
| 53 | **Testing** | 2018-05-23 A |  | 0% → 27% |  |
| 54 | Component tests | 2018-05-23 A |  | 0% → 27% |  |
